# mastering facebook marketing

Schedule from MS Project, 2012-01-09 to 2012-03-27.

## Calendars

- Standard: Mon-Fri 08:00-12:00, 13:00-17:00; Sat-Sun off.

## Schedule

| ID | WBS | Task | Type | Duration | Start | Finish | Predecessors |
| --- | --- | --- | --- | --- | --- | --- | --- |
| 1 | 1 | **Phase 1 - Major preparations** |  | 19d | 2012-01-09 | 2012-02-02 |  |
| 2 | 1.1 | Make list of key needs that must be met by new office space | manual | 2d | 2012-01-09 | 2012-01-10 |  |
| 3 | 1.2 | Identify office space | manual | 3d | 2012-01-11 | 2012-01-13 | 2 |
| 4 | 1.3 | Identify costs for new office (chairs, desks, equipment) | manual | 2d | 2012-01-16 | 2012-01-17 | 3 |
| 5 | 1.4 | Prepare a budget for the move | manual | 2d | 2012-01-18 | 2012-01-19 | 4 |
| 6 | 1.5 | Select the move day | manual | 1d | 2012-01-20 | 2012-01-20 | 5 |
| 7 | 1.6 | Hire contractors for major office improvements | manual | 3d | 2012-01-23 | 2012-01-25 | 6 |
| 8 | 1.7 | Obtain necessary permits | manual | 3d | 2012-01-26 | 2012-01-30 | 7 |
| 9 | 1.8 | Evaluate phone system needs | manual | 1d | 2012-01-31 | 2012-01-31 | 8 |
| 10 | 1.9 | Order new phone number, fax number | manual | 1d | 2012-01-31 | 2012-01-31 | 9SS |
| 11 | 1.10 | Communicate to employees | manual | 1d | 2012-02-01 | 2012-02-01 | 10 |
| 12 | 2 | **Phase 2 - Equip a new office** |  | 20d | 2012-02-02 | 2012-02-29 |  |
| 13 | 2.1 | Design office space | manual | 3d | 2012-02-02 | 2012-02-06 |  |
| 14 | 2.2 | Order furniture and office equipment | manual | 3d | 2012-02-07 | 2012-02-09 | 13 |
| 15 | 2.3 | Hire movers | manual | 1d | 2012-02-10 | 2012-02-10 | 14 |
| 16 | 2.4 | Order nameplate for new location | manual | 2d | 2012-02-13 | 2012-02-14 | 15 |
| 17 | 2.5 | Order phone system | manual | 2d | 2012-02-15 | 2012-02-16 | 16 |
| 18 | 2.6 | Order phone lines | manual | 2d | 2012-02-15 | 2012-02-16 | 17SS |
| 19 | 2.7 | Arrange internal maintenance service | manual | 4d | 2012-02-17 | 2012-02-22 | 18 |
| 20 | 2.8 | Arrange external maintenance service | manual | 4d | 2012-02-17 | 2012-02-22 | 19SS |
| 21 | 2.9 | Purchase insurance for new space | manual | 2d | 2012-02-23 | 2012-02-24 | 20 |
| 22 | 2.10 | Order security system | manual | 2d | 2012-02-27 | 2012-02-28 | 21 |
| 23 | 2.11 | Order keys, access cards | manual | 1d | 2012-02-27 | 2012-02-27 | 22SS |
| 24 | 2.12 | Arrange for beverage service | manual | 1d | 2012-02-27 | 2012-02-27 | 22SS |

| ID | WBS | Task | Type | Duration | Start | Finish | Predecessors |
| --- | --- | --- | --- | --- | --- | --- | --- |
| 25 | 3 | **Phase 3 - Notifications** |  | 16d | 2012-02-02 | 2012-02-23 |  |
| 26 | 3.1 | Send notificatiobs to all vendors, customers, subscriptions | manual | 3d | 2012-02-02 | 2012-02-06 |  |
| 27 | 3.2 | Order new letterhead and envelopes | manual | 2d | 2012-02-07 | 2012-02-08 | 26 |
| 28 | 3.3 | Order new business cards | manual | 2d | 2012-02-07 | 2012-02-08 | 27SS |
| 29 | 3.4 | Create new office layout map | manual | 2d | 2012-02-09 | 2012-02-10 | 28 |
| 30 | 3.5 | Create new fax cover sheet | manual | 1d | 2012-02-13 | 2012-02-13 | 29 |
| 31 | 3.6 | Create driving instructions to new location for employees | manual | 1d | 2012-02-14 | 2012-02-14 | 30 |
| 32 | 3.7 | Obtain public transportation information for new location | manual | 1d | 2012-02-14 | 2012-02-14 | 31SS |
| 33 | 3.8 | Get shipping labels | manual | 2d | 2012-02-15 | 2012-02-16 | 32 |
| 34 | 3.9 | Notify post office of change of address | manual | 1d | 2012-02-17 | 2012-02-17 | 33 |
| 35 | 3.10 | Update company website with new information | manual | 1d | 2012-02-20 | 2012-02-20 | 34 |
| 36 | 3.11 | Code new office space on a map for movers | manual | 2d | 2012-02-21 | 2012-02-22 | 35 |
| 37 | 4 | **Phase 4 - Last preparations before moving day** |  | 14d | 2012-02-29 | 2012-03-19 |  |
| 38 | 4.1 | Plan for disposal of old office equipment and furniture | manual | 4d | 2012-02-29 | 2012-03-05 |  |
| 39 | 4.2 | Dispose of old office equipment and furniture | manual | 4d | 2012-02-29 | 2012-03-05 | 38SS |
| 40 | 4.3 | Install phone lines | manual | 2d | 2012-03-06 | 2012-03-07 | 39 |
| 41 | 4.4 | Install phone system | manual | 2d | 2012-03-06 | 2012-03-07 | 40SS |
| 42 | 4.5 | Assign new phone numbers | manual | 1d | 2012-03-08 | 2012-03-08 | 41 |
| 43 | 4.6 | Clean new office | manual | 2d | 2012-03-09 | 2012-03-12 |  |
| 44 | 4.7 | Purge old, obsolete materials | manual | 2d | 2012-03-13 | 2012-03-14 | 43 |
| 45 | 4.8 | Order moving boxes | manual | 1d | 2012-03-13 | 2012-03-13 | 44SS |
| 46 | 4.9 | Pack up desks, personal spaces | manual | 2d | 2012-03-13 | 2012-03-14 | 45SS |
| 47 | 4.10 | Pack up common areas | manual | 2d | 2012-03-13 | 2012-03-14 | 46SS |
| 48 | 4.11 | Label all fragile items | manual | 2d | 2012-03-13 | 2012-03-14 | 47SS |
| 49 | 4.12 | Store property that will not be moved | manual | 1d | 2012-03-15 | 2012-03-15 | 48 |
| 50 | 4.13 | Label furniture to be moved | manual | 1d | 2012-03-15 | 2012-03-15 | 49SS |
| 51 | 4.14 | Install network wiring at new location | manual | 2d | 2012-03-08 | 2012-03-09 | 41 |
| 52 | 4.15 | Distribute new keys, cards | manual | 1d | 2012-03-16 | 2012-03-16 |  |
| 53 | 4.16 | Collect old keys, cards | manual | 1d | 2012-03-16 | 2012-03-16 | 52SS |
| 54 | 4.17 | Empty, defrost and clean refrigerator | manual | 1d | 2012-03-16 | 2012-03-16 | 53SS |
| 55 | 4.18 | Create a moving day team to provide direction to movers | manual | 1d | 2012-03-16 | 2012-03-16 | 54SS |

| ID | WBS | Task | Type | Duration | Start | Finish | Predecessors |
| --- | --- | --- | --- | --- | --- | --- | --- |
| 56 | 5 | **Phase 5 - Moving Day** |  | 2d | 2012-03-19 | 2012-03-20 |  |
| 57 | 5.1 | Put moving day team in place | manual | 1d | 2012-03-19 | 2012-03-19 |  |
| 58 | 5.2 | Move plants and fine art in separate moving van | manual | 1d | 2012-03-19 | 2012-03-19 | 57SS |
| 59 | 5.3 | Complete physical move | manual | 1d | 2012-03-19 | 2012-03-19 | 58SS |
| 60 | 6 | **Phase 6 - Post Move** |  | 6d | 2012-03-20 | 2012-03-27 |  |
| 61 | 6.1 | Check carefully for any damaged or missing items | manual | 5d | 2012-03-20 | 2012-03-26 |  |
| 62 | 6.2 | Periodically visit old office to pick up mail | manual | 5d | 2012-03-20 | 2012-03-26 |  |
| 63 | 6.3 | Schedule open house for clients | manual | 1d | 2012-03-23 | 2012-03-23 |  |
