Schedule from MS Project, 2003-03-08 to 2003-07-02, A marks actual dates.
Xpress Systems

## Calendars

- Standard: Mon-Fri 08:00-12:00, 13:00-17:00; Sat-Sun off.

## Resources

| Resource |
| --- |
| PM |
| QAM |
| DB DEV |
| Dev |
| QAE |
| MW |
| SA |
| PC |
| CM |

## Schedule

| ID | WBS | Task | Duration | Start | Finish | Predecessors | Complete | Remaining | Baseline start | Baseline finish | Baseline duration | Total slack | Free slack | Constraint | Resources | Work | Actual work |
| --- | --- | --- | --- | --- | --- | --- | --- | --- | --- | --- | --- | --- | --- | --- | --- | --- | --- |
| 1 | 1 | **Sample Project** | 82.25d | 2003-03-08 A | 2003-07-02 |  | 1% | 81.45d | 2003-01-17 | 2003-03-06 | 103.12d | 0d |  |  |  | 1758h | 12h |
| 2 | 1.1 | **Gather customer requirements and proposed solutions** | 7d | 2003-03-08 A | 2003-03-18 |  | 21% | 5.5d | 2003-01-17 | 2003-01-21 | 7.12d | 0d |  |  |  | 72h | 12h |
| 3 | 1.01 | Collect project ideas & requirements from a customer | 3d | 2003-03-08 A | 2003-03-12 |  | 50% | 1.5d | 2003-01-17 | 2003-01-21 | 3d | 0d |  | start no earlier than 2003-01-17 | PM | 24h | 12h |
| 4 | 3.02 | Prepare internal estimation | 2d | 2003-03-13 | 2003-03-14 | 3 |  |  | 2003-01-23 | 2003-01-24 | 2d | 0d |  |  | PM; SA | 32h |  |
| 5 | 1.1.3 | Prepare project scope | 2d | 2003-03-17 | 2003-03-18 | 4 |  |  |  |  |  | 0d |  |  | PM | 16h |  |
| 6 | 1.2 | **Customer Approval** | 2d | 2003-03-19 | 2003-03-20 |  |  |  | 2003-01-20 | 2003-01-22 | 7.12d | 0d |  |  |  | 24h |  |
| 7 | 2.01 | Approve / Modify estimation and project scope | 1d | 2003-03-19 | 2003-03-19 | 5 |  |  | 2003-01-20 | 2003-01-22 | 3d | 0d |  | start no earlier than 2003-03-03 | PC | 8h |  |
| 8 | 2.02 | Present estimation and project scope to customer and get approval | 1d | 2003-03-20 | 2003-03-20 | 7 |  |  | 2003-01-20 | 2003-01-20 | 1d | 0d |  | start no earlier than 2003-01-21 | PC; PM | 16h |  |
| 9 | 1.3 | **Analysis** | 5.5d | 2003-03-21 | 2003-03-28 |  |  |  | 2003-01-20 | 2003-01-22 | 7.12d | 0d |  |  |  | 48h |  |
| 10 | 2.01 | Create project plan | 2h | 2003-03-21 | 2003-03-21 | 8 |  |  | 2003-01-20 | 2003-01-22 | 3d | 0d |  | start no earlier than 2003-03-03 | PM; QAM | 4h |  |
| 11 | 2.02 | Write functional specification | 20h | 2003-03-21 | 2003-03-25 | 10 |  |  | 2003-01-20 | 2003-01-20 | 1d | 0d |  | start no earlier than 2003-01-21 | PM | 20h |  |
| 12 | 1.3.3 | Create builds schedule | 2h | 2003-03-25 | 2003-03-25 | 11 |  |  |  |  |  | 0d |  |  | PM; QAM | 4h |  |
| 13 | 1.3.4 | Create UML model, including DFD | 12h | 2003-03-26 | 2003-03-27 | 12 |  |  |  |  |  | 0d |  |  | SA | 12h |  |
| 14 | 1.3.5 | Create entity relationship diagram (ERD) | 8h | 2003-03-27 | 2003-03-28 | 13 |  |  |  |  |  | 0d |  |  | DB DEV | 8h |  |
| 15 | 1.4 | **Design** | 5d | 2003-03-28 | 2003-04-04 |  |  |  | 2003-01-23 | 2003-01-30 | 16.12d | 0d |  |  |  | 112h |  |
| 16 | 3.01 | Design data model | 3d | 2003-03-28 | 2003-04-02 | 14 |  |  | 2003-01-23 | 2003-01-24 | 2d | 0d |  |  | DB DEV | 24h |  |
| 17 | 3.04 | Write detailed design specifications | 5d | 2003-03-28 | 2003-04-04 | 14 |  |  | 2003-01-29 | 2003-01-30 | 2d | 42.75d | 0d | start no earlier than 2003-03-03 | Dev | 40h |  |
| 18 | 3.07 | Write SQA test plan | 12h | 2003-03-28 | 2003-03-31 | 14 |  |  | 2003-01-29 | 2003-01-29 | 1d | 23.25d | 0d |  | QAE; QAM | 24h |  |
| 19 | 3.08 | Write SQA test cases | 3d | 2003-04-01 | 2003-04-03 | 18 |  |  | 2003-01-30 | 2003-01-30 | 1d | 23.25d | 0d |  | QAE | 24h |  |
| 20 | 1.5 | **Development** | 22d | 2003-04-02 | 2003-05-02 |  |  |  | 2003-01-31 | 2003-02-20 | 43.12d | 0d |  |  |  | 319h |  |
| 21 | 4.02 | Unit development | 20d | 2003-04-04 | 2003-05-02 | 17 |  |  | 2003-01-31 | 2003-02-06 | 5d | 42.75d |  | finish no earlier than 2003-02-06 | Dev | 160h |  |
| 22 | 4.03 | Database design | 12d | 2003-04-02 | 2003-04-18 | 16 |  |  | 2003-02-07 | 2003-02-13 | 40h | 0d |  | finish no earlier than 2003-02-06 | DB DEV | 96h |  |
| 23 | 1.5.3 | Unit test | 3d | 2003-04-18 | 2003-04-23 | 22 |  |  |  |  |  | 0d |  |  | Dev; DB DEV | 48h |  |
| 24 | 1.5.4 | Build assembly | 4h | 2003-04-23 | 2003-04-23 | 23 |  |  |  |  |  | 0d |  |  | Dev | 4h |  |
| 25 | 1.5.5 | Integration test | 8h | 2003-04-24 | 2003-04-24 | 24 |  |  |  |  |  | 0d |  |  | Dev | 8h |  |
| 26 | 1.5.6 | Build release for testing | 3h | 2003-04-25 | 2003-04-25 | 25 |  |  |  |  |  | 0d |  |  | Dev | 3h |  |

| ID | WBS | Task | Duration | Start | Finish | Predecessors | Baseline start | Baseline finish | Baseline duration | Total slack | Resources | Work |
| --- | --- | --- | --- | --- | --- | --- | --- | --- | --- | --- | --- | --- |
| 27 | 1.6 | **Test (Software Quality Assurance - SQA)** | 22.75d | 2003-04-04 | 2003-05-06 |  | 2003-02-14 | 2003-03-06 | 43.12d | 15.38d |  | 83h |
| 28 | 1.6.1 | Write SQA test cases | 3d | 2003-04-04 | 2003-04-08 | 19 |  |  |  | 60.25d | QAE | 24h |
| 29 | 5.01 | Build testing | 7d | 2003-04-25 | 2003-05-06 | 26 | 2003-02-14 | 2003-02-27 | 10d | 0d | QAE | 56h |
| 30 | 5.03 | Build release | 3h | 2003-05-06 | 2003-05-06 | 29 | 2003-02-28 | 2003-03-06 | 5d | 0d | Dev | 3h |
| 31 | 1.7 | **Implementation** | 21.5d | 2003-05-06 | 2003-06-05 |  | 2003-03-06 | 2003-03-06 | 1.12d | 0d |  | 372h |
| 32 | 7.01 | Install beta test system at customer’s location | 4h | 2003-05-06 | 2003-05-07 | 30 | 2003-03-06 | 2003-03-06 | 0d | 0d | PM | 4h |
| 33 | 7.02 | Conduct beta tests | 2d | 2003-05-07 | 2003-05-09 | 32 | 2003-03-06 | 2003-03-06 | 0d | 0d | PM; CM | 32h |
| 34 | 7.03 | Train users | 2d | 2003-05-09 | 2003-05-13 | 33 | 2003-03-06 | 2003-03-06 | 0d | 0d | PM | 16h |
| 35 | 1.7.4 | Sign-off first version with customer | 1d | 2003-05-13 | 2003-05-14 | 34 |  |  |  | 0d | PC; PM | 16h |
| 36 | 7.04 | Gather new version requirements for customizations & change requests | 3d | 2003-05-14 | 2003-05-19 | 35 | 2003-03-06 | 2003-03-06 | 0d | 0d | PM | 24h |
| 37 | 1.7.6 | Approve changes with project coordinator & customer (if changes are out of initial scope) | 1d | 2003-05-19 | 2003-05-20 | 36 |  |  |  | 0d | PM; PC | 16h |
| 38 | 1.7.7 | Adjust Project documentation | 1d | 2003-05-20 | 2003-05-21 | 37 |  |  |  | 0d | DB DEV; Dev; QAE; PM; SA | 40h |
| 39 | 1.7.8 | Implement requested changes | 8d | 2003-05-21 | 2003-06-02 | 38 |  |  |  | 0d | DB DEV; Dev; QAE | 192h |
| 40 | 1.7.9 | Product release | 1d | 2003-06-02 | 2003-06-03 | 39 |  |  |  | 0d | PM; QAM | 16h |
| 41 | 1.7.10 | Product deployment | 2d | 2003-06-03 | 2003-06-05 | 40 |  |  |  | 0d | PM | 16h |
| 42 | 1.8 | **Documentation** | 40d | 2003-04-04 | 2003-05-29 |  |  |  |  | 23.25d |  | 320h |
| 43 | 1.8.1 | Manual Writing | 40d | 2003-04-04 | 2003-05-29 | 19 |  |  |  | 23.25d | MW | 320h |
| 44 | 1.9 | **Product Support** | 19d | 2003-06-05 | 2003-07-02 |  |  |  |  | 0d |  | 408h |
| 45 | 1.9.1 | Gather changes requests | 3d | 2003-06-05 | 2003-06-10 | 41 |  |  |  | 0d | PM | 24h |
| 46 | 1.9.2 | Prepare estimation | 8h | 2003-06-10 | 2003-06-11 | 45 |  |  |  | 0d | PM; PC; SA | 24h |
| 47 | 1.9.3 | Approve changes with customer | 1d | 2003-06-11 | 2003-06-12 | 46 |  |  |  | 0d | PM; PC | 16h |
| 48 | 1.9.4 | Adjust project documentation | 3d | 2003-06-12 | 2003-06-17 | 47 |  |  |  | 0d | DB DEV; Dev; QAE; SA; PM | 120h |
| 49 | 1.9.5 | Implement requested changes | 8d | 2003-06-17 | 2003-06-27 | 48 |  |  |  | 0d | DB DEV; Dev; QAE | 192h |
| 50 | 1.9.6 | New version release | 1d | 2003-06-27 | 2003-06-30 | 49 |  |  |  | 0d | PM; QAM | 16h |
| 51 | 1.9.7 | New version deployment | 1d | 2003-06-30 | 2003-07-01 | 50 |  |  |  | 0d | PM | 8h |
| 52 | 1.9.8 | Sign-off project with customer | 1d | 2003-07-01 | 2003-07-02 | 51 |  |  |  | 0d | PC | 8h |
